# Project Schedule Phase 1 and 2

How a schedule from MS Project changed from version to version. A marks actual dates.

## Version 1 (saved 2001-09-04, file Project Schedule Phase 1 and 2 (rev 3).mpp)

| ID | WBS | Task | Duration | Start | Finish | Predecessors | Complete | Total float | Constraint |
| --- | --- | --- | --- | --- | --- | --- | --- | --- | --- |
| 1 | 1 | **PHASE I** | 65.75d | 2001-08-01 08:00 A | 2001-11-01 15:00 |  | 19% | 0d | start no earlier than 2001-08-01 08:00 |
| 3 | 1.1 | **Project Planning and Specification** | 8.5d | 2001-08-01 08:00 A | 2001-08-13 12:00 |  | 87% | 16.25d |  |
| 5 |  | Develop project schedule and task breakdown | 12h | 2001-08-01 08:00 A | 2001-08-02 12:00 A |  | 100% |  |  |
| 6 |  | Reserve 7k records for Phase II QC needs. | 1h | 2001-08-02 13:00 A | 2001-08-02 14:00 A | 5 | 100% |  |  |
| 7 |  | Rework 6046 SW specification | 36h | 2001-08-02 14:00 A | 2001-08-09 09:00 | 6 | 90% | 18.31d |  |
| 8 |  | QC proposal | 10h | 2001-08-09 09:00 A | 2001-08-10 11:00 | 7 | 50% | 17.38d |  |
| 9 |  | Rework project schedule | 4h | 2001-08-10 11:00 A | 2001-08-10 16:00 A | 8 | 100% |  |  |
| 10 |  | Define 7k records for command and control ASCII protocol. | 3h | 2001-08-10 16:00 A | 2001-08-13 10:00 A | 9 | 100% |  |  |
| 11 |  | Define 7k records for EdgeTech SSS, SBP and sundry sensors | 2h | 2001-08-13 10:00 A | 2001-08-13 12:00 | 10 | 75% | 16.25d |  |
| 13 | 1.2 | **Wet End** | 40.38d | 2001-08-27 08:00 A | 2001-10-23 11:00 | 3 | 16% | 0.88d | start no earlier than 2001-08-27 08:00 |
| 15 | 1.2.1 | **General** | 9.75d | 2001-08-27 08:00 A | 2001-09-10 15:00 | 3 | 51% | 1.75d |  |
| 17 |  | Time, timing and general support classes. | 32h | 2001-08-27 08:00 A | 2001-08-30 17:00 | 11 | 75% | 3.75d |  |
| 18 |  | Socket support classes. | 16h | 2001-08-31 08:00 A | 2001-09-04 17:00 | 17 | 75% | 2.25d |  |
| 19 |  | 7k protocol, disk I/0 and socket framing API (DLL). | 16h | 2001-09-05 08:00 A | 2001-09-06 17:00 | 18 | 25% | 1.75d |  |
| 20 |  | Command and control protocol API. | 8h | 2001-09-07 08:00 | 2001-09-07 17:00 | 19 |  | 1.75d |  |
| 21 |  | Testing | 6h | 2001-09-10 08:00 | 2001-09-10 15:00 | 20 |  | 1.75d |  |
| 23 | 1.2.2 | **EdgeTech Integration** | 8.25d | 2001-09-10 15:00 A | 2001-09-20 17:00 | 15 | 5% | 1.38d |  |
| 25 |  | EdgeTech simulator configuration | 2h | 2001-09-10 15:00 A | 2001-09-10 17:00 | 21 | 50% | 9.38d |  |
| 26 |  | Create DLL and framework. | 2h | 2001-09-11 08:00 A | 2001-09-11 10:00 A | 25 | 100% |  |  |
| 27 |  | Message handler and socket reciever threads | 8h | 2001-09-11 10:00 | 2001-09-12 10:00 | 26 |  | 1.38d |  |
| 28 |  | Command and cotrol framework. | 8h | 2001-09-12 10:00 | 2001-09-13 10:00 | 27 |  | 1.38d |  |
| 29 |  | Data collection framework. | 8h | 2001-09-13 10:00 | 2001-09-14 10:00 | 28 |  | 1.38d |  |
| 30 |  | Ping/channel sequencer. | 16h | 2001-09-14 10:00 | 2001-09-18 10:00 | 29 |  | 1.38d |  |
| 31 |  | Sonar configuration save / restore settings. | 6h | 2001-09-18 10:00 | 2001-09-18 17:00 | 30 |  | 1.38d |  |
| 32 |  | Sonar command set for remote and startup control. | 4h | 2001-09-19 08:00 | 2001-09-19 12:00 | 31 |  | 1.38d |  |
| 33 |  | Synchronize FS-AS and payload controller clocks. | 2h | 2001-09-19 13:00 | 2001-09-19 15:00 | 32 |  | 1.38d |  |
| 34 |  | Per channel emulation support (I.e., test patterns). | 2h | 2001-09-19 15:00 | 2001-09-19 17:00 | 33 |  | 1.38d |  |
| 35 |  | Testing. | 8h | 2001-09-20 08:00 | 2001-09-20 17:00 | 34 |  | 1.38d |  |
| 37 | 1.2.3 | **Payload Controller** | 22.38d | 2001-09-21 08:00 A | 2001-10-23 11:00 | 23 | 5% | 0.88d |  |
| 39 | 1.2.3.1 | **General** | 8d | 2001-09-21 08:00 A | 2001-10-02 17:00 |  | 6% | 1.5d |  |
| 41 |  | Service restructure (polled acquisition cycle, socket exchange, command handler, infrustruture). | 16h | 2001-09-21 08:00 A | 2001-09-24 17:00 | 35 | 25% | 1.5d |  |
| 42 |  | Integrate new sensor list (DLL registration). | 4h | 2001-09-25 08:00 | 2001-09-25 12:00 | 41 |  | 0.88d |  |
| 43 |  | Rework message handler to be driven by 7k protocol | 16h | 2001-09-25 13:00 | 2001-09-27 12:00 | 42 |  | 0.88d |  |
| 44 |  | Expand saved and restored parameter list (includes sensor state). | 4h | 2001-09-27 13:00 | 2001-09-27 17:00 | 43 |  | 0.88d |  |
| 45 |  | UTC time synchronization support. | 4h | 2001-09-28 08:00 | 2001-09-28 12:00 | 44 |  | 0.88d |  |
| 46 |  | Supervise new sensors. | 8h | 2001-09-28 13:00 | 2001-10-01 12:00 | 45 |  | 0.88d |  |
| 47 |  | Command routing | 4h | 2001-10-01 13:00 | 2001-10-01 17:00 | 46 |  | 0.88d |  |
| 48 |  | Testing | 8h | 2001-10-02 08:00 | 2001-10-02 17:00 | 47 |  | 0.88d |  |
| 50 | 1.2.3.2 | **Logging** | 2.88d | 2001-10-03 08:00 | 2001-10-05 16:00 |  |  | 1.5d |  |
| 52 |  | Record sequencing and logging support class(es). | 8h | 2001-10-03 08:00 | 2001-10-03 17:00 | 48 |  | 0.88d |  |
| 53 |  | Integrate 7k logging API. | 4h | 2001-10-04 08:00 | 2001-10-04 12:00 | 52 |  | 0.88d |  |
| 54 |  | Auto change of file names on file size and named logging based on time. | 2h | 2001-10-04 13:00 | 2001-10-04 15:00 | 53 |  | 0.88d |  |
| 55 |  | Periodically flush logging buffers (minimize potential data loss in event of system crash). | 1h | 2001-10-04 15:00 | 2001-10-04 16:00 | 54 |  | 0.88d |  |
| 56 |  | Testing | 8h | 2001-10-04 16:00 | 2001-10-05 16:00 | 55 |  | 0.88d |  |
| 58 | 1.2.3.3 | **Survey Event Log** | 1.75d | 2001-10-05 16:00 A | 2001-10-09 14:00 |  | 36% | 0.88d |  |
| 59 |  | Re-work infrustructure | 10h | 2001-10-05 16:00 A | 2001-10-09 09:00 | 56 | 50% | 0.88d |  |
| 60 |  | Testing | 4h | 2001-10-09 09:00 | 2001-10-09 14:00 | 59 |  | 0.88d |  |
| 62 | 1.2.3.4 | **Alarm and Status Monitoring** | 3.25d | 2001-10-09 14:00 | 2001-10-12 16:00 |  |  | 0.88d |  |
| 63 |  | Infrastructure | 8h | 2001-10-09 14:00 | 2001-10-10 14:00 | 60 |  | 0.88d |  |
| 64 |  | Status monitoring | 8h | 2001-10-10 14:00 | 2001-10-11 14:00 | 63 |  | 0.88d |  |
| 65 |  | Messaging to client(s) and Survey Event Log | 6h | 2001-10-11 14:00 | 2001-10-12 11:00 | 64 |  | 0.88d |  |
| 66 |  | Testing | 4h | 2001-10-12 11:00 | 2001-10-12 16:00 | 65 |  | 0.88d |  |
| 68 | 1.2.3.5 | **Trigger Controller** | 2.5d | 2001-10-12 16:00 | 2001-10-17 11:00 |  |  | 0.88d |  |
| 69 |  | Interface definition | 8h | 2001-10-12 16:00 | 2001-10-15 16:00 | 66 |  | 0.88d |  |
| 70 |  | Interface to payload controller. | 4h | 2001-10-15 16:00 | 2001-10-16 11:00 | 69 |  | 0.88d |  |
| 71 |  | Software trigger scheme | 4h | 2001-10-16 11:00 | 2001-10-16 16:00 | 70 |  | 0.88d |  |
| 72 |  | Testing | 4h | 2001-10-16 16:00 | 2001-10-17 11:00 | 71 |  | 0.88d |  |
| 74 | 1.2.3.6 | **Vehicle Interfacing** | 4d | 2001-10-17 11:00 | 2001-10-23 11:00 |  |  | 0.88d |  |
| 76 |  | Infrastructure. | 4h | 2001-10-17 11:00 | 2001-10-17 16:00 | 72 |  | 0.88d |  |
| 77 |  | Interface to Vehicle computer. | 8h | 2001-10-17 16:00 | 2001-10-18 16:00 | 76 |  | 0.88d |  |
| 78 |  | Interface to CAN system | 8h | 2001-10-18 16:00 | 2001-10-19 16:00 | 77 |  | 0.88d |  |
| 79 |  | Benchmark testing of 100 Hz update rates. | 4h | 2001-10-19 16:00 | 2001-10-22 11:00 | 78 |  | 0.88d |  |
| 80 |  | Data formatting | 4h | 2001-10-22 11:00 | 2001-10-22 16:00 | 79 |  | 0.88d |  |
| 81 |  | Testing. | 4h | 2001-10-22 16:00 | 2001-10-23 11:00 | 80 |  | 0.88d |  |
| 83 | 1.3 | **Dry End** | 38.75d | 2001-08-27 08:00 A | 2001-10-19 15:00 |  | 12% | 0d | start no earlier than 2001-08-27 08:00 |
| 85 | 1.3.1 | **Prototyping** | 11d | 2001-08-27 08:00 A | 2001-09-11 17:00 |  | 41% | 0d |  |
| 87 |  | Waterfall display class(es) | 48h | 2001-08-27 08:00 A | 2001-09-04 17:00 |  | 75% | 0d |  |
| 88 |  | Timeseries plot class(es) | 40h | 2001-09-05 08:00 | 2001-09-11 17:00 | 87 |  | 0d |  |
| 90 | 1.3.2 | **Infrastructure** | 11d | 2001-09-12 08:00 | 2001-09-26 17:00 | 85 |  | 0d |  |
| 92 |  | Restructure framework | 40h | 2001-09-12 08:00 | 2001-09-18 17:00 | 88 |  | 0d |  |

| ID | WBS | Task | Duration | Start | Finish | Predecessors | Total float |
| --- | --- | --- | --- | --- | --- | --- | --- |
| 93 |  | Per sensor setup and control page | 16h | 2001-09-19 08:00 | 2001-09-20 17:00 | 92 | 0d |
| 94 |  | Message handler object and integration of 7k protocol/socket API. | 16h | 2001-09-21 08:00 | 2001-09-24 17:00 | 93 | 0d |
| 95 |  | 7k file replay mechanism and integration of 7k data replay DLL | 16h | 2001-09-25 08:00 | 2001-09-26 17:00 | 94 | 0d |
| 97 | 1.3.3 | **Visualization Displays for Playback** | 12d | 2001-09-27 08:00 | 2001-10-12 17:00 | 90 | 0d |
| 99 |  | Integrate 7k command protocol API | 8h | 2001-09-27 08:00 | 2001-09-27 17:00 | 95 | 0d |
| 100 |  | Data scaling and pre-processing | 16h | 2001-09-28 08:00 | 2001-10-01 17:00 | 99 | 0d |
| 101 |  | Integrate waterfall display for SSS. | 12h | 2001-10-02 08:00 | 2001-10-03 12:00 | 100 | 0d |
| 102 |  | Integrate waterfall display for SBP. | 12h | 2001-10-03 13:00 | 2001-10-04 17:00 | 101 | 0d |
| 103 |  | Integrate time series plot graphics and parameter mapping. | 16h | 2001-10-05 08:00 | 2001-10-08 17:00 | 102 | 0d |
| 104 |  | Tables of position updates. | 8h | 2001-10-09 08:00 | 2001-10-09 17:00 | 103 | 0d |
| 105 |  | Summary display for ping / time data | 8h | 2001-10-10 08:00 | 2001-10-10 17:00 | 104 | 0d |
| 106 |  | Testing | 16h | 2001-10-11 08:00 | 2001-10-12 17:00 | 105 | 0d |
| 108 | 1.3.4 | **GUIs for payload controller** | 4.75d | 2001-10-15 08:00 | 2001-10-19 15:00 | 97 | 0d |
| 110 |  | Setup, control and status review of sensors (sensor specific). | 20h | 2001-10-15 08:00 | 2001-10-17 12:00 | 106 | 0d |
| 111 |  | GUI for setup and synchronization scheme. | 10h | 2001-10-17 13:00 | 2001-10-18 15:00 | 110 | 0d |
| 112 |  | Sensor data received summary page | 8h | 2001-10-18 15:00 | 2001-10-19 15:00 | 111 | 0d |
| 114 | 1.4 | **Installation Program** | 2.5d | 2001-10-19 15:00 | 2001-10-24 10:00 | 108, 83 | 0d |
| 116 |  | Generate install scripts | 16h | 2001-10-19 15:00 | 2001-10-23 15:00 | 112 | 0d |
| 117 |  | Testing | 4h | 2001-10-23 15:00 | 2001-10-24 10:00 | 116 | 0d |
| 119 | 1.5 | **Integration testing** | 4.5d | 2001-10-24 10:00 | 2001-10-30 15:00 | 114, 37, 13 | 0d |
| 121 |  | Setup hardware | 4h | 2001-10-24 10:00 | 2001-10-24 15:00 | 81 | 0d |
| 122 |  | Configure software and tools | 4h | 2001-10-24 10:00 | 2001-10-24 15:00 | 117 | 0d |
| 123 |  | Testing and debugging | 32h | 2001-10-24 15:00 | 2001-10-30 15:00 | 121, 122 | 0d |
| 125 | 1.6 | **Utilities** | 2d | 2001-10-30 15:00 | 2001-11-01 15:00 | 119 | 0d |
| 127 |  | 7k to XTF conversion utility | 16h | 2001-10-30 15:00 | 2001-11-01 15:00 | 123 | 0d |
| 129 | 2 | **PHASE II** | 37.5d | 2001-11-01 15:00 | 2001-12-25 10:00 | 1, 125 | 0d |
| 131 | 2.1 | **Wet End** | 7.5d | 2001-11-01 15:00 | 2001-11-13 10:00 |  | 0d |
| 133 |  | Direct logging of XTF | 16h | 2001-11-01 15:00 | 2001-11-05 15:00 | 127 | 0d |
| 134 |  | Data messages for realtime display | 16h | 2001-11-05 15:00 | 2001-11-07 15:00 | 133 | 0d |
| 135 |  | Collect logging statistics | 4h | 2001-11-07 15:00 | 2001-11-08 10:00 | 134 | 0d |
| 136 |  | Re-work Timing Controller for HW supervision | 24h | 2001-11-08 10:00 | 2001-11-13 10:00 | 135 | 0d |
| 138 | 2.2 | **Dry End** | 0.5d | 2001-11-01 15:00 | 2001-11-02 10:00 | 119 | 37d |
| 140 |  | Realtime display integration | 4h | 2001-11-01 15:00 | 2001-11-02 10:00 | 123 | 37d |
| 142 | 2.3 | **QC (TBD - Subject to proposal acceptance)** | 30d | 2001-11-13 10:00 | 2001-12-25 10:00 | 131 | 0d |
| 143 |  | TBD | 240h | 2001-11-13 10:00 | 2001-12-25 10:00 | 136 | 0d |
| 145 |  | Initial release | 0h | 2001-10-30 15:00 | 2001-10-30 15:00 | 119 | 39.5d |
| 146 |  | Final release | 0h | 2001-12-25 10:00 | 2001-12-25 10:00 | 129, 142, 138, 140 | 0d |
| 148 | 5 | **PHASE III (unscheduled - future work)** | 0d | 2001-07-30 08:00 | 2001-07-30 08:00 |  | 105.25d |
| 150 | 5.1 | **Dry End** | 0d | 2001-07-30 08:00 | 2001-07-30 08:00 |  | 105.25d |
| 151 |  | File transfer GUI and control. | 0h | 2001-07-30 08:00 | 2001-07-30 08:00 |  | 105.25d |
| 153 | 5.2 | **Wet End** | 0d | 2001-07-30 08:00 | 2001-07-30 08:00 |  | 105.25d |
| 155 |  | File transferPLC support. | 0h | 2001-07-30 08:00 | 2001-07-30 08:00 |  | 105.25d |
| 156 |  | Serial port handler w/ time tagging. | 0h | 2001-07-30 08:00 | 2001-07-30 08:00 |  | 105.25d |
| 157 |  | Optionally send Patch Test messages. | 0h | 2001-07-30 08:00 | 2001-07-30 08:00 |  | 105.25d |
| 158 |  | Interface to 6041. | 0h | 2001-07-30 08:00 | 2001-07-30 08:00 |  | 105.25d |

## Version 2 (saved 2001-09-09, file Project Schedule Phase 1 and 2 (rev 4).mpp)

Last finish 2001-12-25 → 2001-12-24 (-1d). Complete tasks 5 → 4.

Changed:

| ID | Task | Start | Finish | Duration | Complete | Total float | Predecessors | Other |
| --- | --- | --- | --- | --- | --- | --- | --- | --- |
| 1 | **PHASE I** | 2001-08-01 08:00 A → 2001-08-13 08:00 A (+12d) | 2001-11-01 15:00 → 2001-11-01 10:00 | 65.75d → 58.25d? | 19% → 21% |  |  | constraint start no earlier than 2001-08-01 08:00 → none; baseline start 2001-08-01 08:00 → 2001-08-13 08:00; baseline finish 2001-11-01 15:00 → 2001-11-01 10:00 |
| 3 | **Project Planning and Specification** | 2001-08-01 08:00 A → 2001-08-13 08:00 A (+12d) | 2001-08-13 12:00 → 2001-08-23 12:00 (+10d) |  | 87% → 88% | 16.25d → 8.44d |  | baseline start 2001-08-01 08:00 → 2001-08-13 08:00; baseline finish 2001-08-13 12:00 → 2001-08-23 12:00 |
| 5 | Develop project schedule and task breakdown | 2001-08-01 08:00 A → 2001-08-13 08:00 A (+12d) | 2001-08-02 12:00 A → 2001-08-14 12:00 A (+12d) |  |  |  |  | constraint none → start no earlier than 2001-08-13 08:00; baseline start 2001-08-01 08:00 → 2001-08-13 08:00; baseline finish 2001-08-02 12:00 → 2001-08-14 12:00 |
| 6 | Reserve 7k records for Phase II QC needs. | 2001-08-02 13:00 A → 2001-08-14 13:00 A (+12d) | 2001-08-02 14:00 A → 2001-08-14 14:00 A (+12d) |  |  |  |  | baseline start 2001-08-02 13:00 → 2001-08-14 13:00; baseline finish 2001-08-02 14:00 → 2001-08-14 14:00 |
| 7 | Rework 6046 SW specification | 2001-08-02 14:00 A → 2001-08-14 14:00 A (+12d) | 2001-08-09 09:00 → 2001-08-21 09:00 (+12d) |  |  | 18.31d → 7.81d |  | baseline start 2001-08-02 14:00 → 2001-08-14 14:00; baseline finish 2001-08-09 09:00 → 2001-08-21 09:00 |
| 8 | QC proposal | 2001-08-09 09:00 A → 2001-08-21 09:00 A (+12d) | 2001-08-10 11:00 → 2001-08-22 11:00 (+12d) |  | 50% → 70% | 17.38d → 9.56d |  | baseline start 2001-08-09 09:00 → 2001-08-21 09:00; baseline finish 2001-08-10 11:00 → 2001-08-22 11:00 |
| 9 | Rework project schedule | 2001-08-10 11:00 A → 2001-08-22 11:00 A (+12d) | 2001-08-10 16:00 A → 2001-08-22 16:00 A (+12d) |  |  |  |  | baseline start 2001-08-10 11:00 → 2001-08-22 11:00; baseline finish 2001-08-10 16:00 → 2001-08-22 16:00 |
| 10 | Define 7k records for command and control ASCII protocol. | 2001-08-10 16:00 A → 2001-08-22 16:00 A (+12d) | 2001-08-13 10:00 A → 2001-08-23 10:00 (+10d) |  | 100% → 75% | none → 5.94d |  | baseline start 2001-08-10 16:00 → 2001-08-22 16:00; baseline finish 2001-08-13 10:00 → 2001-08-23 10:00 |
| 11 | Define 7k records for EdgeTech SSS, SBP and sundry sensors | 2001-08-13 10:00 A → 2001-08-23 10:00 A (+10d) | 2001-08-13 12:00 → 2001-08-23 12:00 (+10d) |  |  | 16.25d → 5.75d |  | baseline start 2001-08-13 10:00 → 2001-08-23 10:00; baseline finish 2001-08-13 12:00 → 2001-08-23 12:00 |
| 13 | **Wet End** | 2001-08-27 08:00 A → 2001-08-23 13:00 A (-4d) | 2001-10-23 11:00 → 2001-10-22 16:00 (-1d) | 40.38d → 42.38d? | 16% → 19% | 0.88d → 0.38d |  | constraint start no earlier than 2001-08-27 08:00 → none; baseline start 2001-08-27 08:00 → 2001-08-23 13:00; baseline finish 2001-10-23 11:00 → 2001-10-22 16:00 |
| 15 | **General** | 2001-08-27 08:00 A → 2001-08-23 13:00 A (-4d) | 2001-09-10 15:00 → 2001-09-06 10:00 (-4d) |  | 51% → 67% | 1.75d → 1.62d | 3 → none | baseline start 2001-08-27 08:00 → 2001-08-23 13:00; baseline finish 2001-09-10 15:00 → 2001-09-06 10:00 |
| 17 | Time, timing and general support classes. | 2001-08-27 08:00 A → 2001-08-23 13:00 A (-4d) | 2001-08-30 17:00 → 2001-08-29 12:00 (-1d) |  | 75% → 90% | 3.75d → 4.15d |  | baseline start 2001-08-27 08:00 → 2001-08-23 13:00; baseline finish 2001-08-30 17:00 → 2001-08-29 12:00 |
| 18 | Socket support classes. | 2001-08-31 08:00 A → 2001-08-29 13:00 A (-2d) | 2001-09-04 17:00 → 2001-08-31 12:00 (-4d) |  | 75% → 85% | 2.25d → 2.45d |  | baseline start 2001-08-31 08:00 → 2001-08-29 13:00; baseline finish 2001-09-04 17:00 → 2001-08-31 12:00 |
| 19 | 7k protocol, disk I/0 and socket framing API (DLL). | 2001-09-05 08:00 A → 2001-08-31 13:00 A (-5d) | 2001-09-06 17:00 → 2001-09-04 12:00 (-2d) |  | 25% → 60% | 1.75d → 1.25d |  | baseline start 2001-09-05 08:00 → 2001-08-31 13:00; baseline finish 2001-09-06 17:00 → 2001-09-04 12:00 |
| 20 | Command and control protocol API. | 2001-09-07 08:00 → 2001-09-04 13:00 (-3d) | 2001-09-07 17:00 → 2001-09-05 12:00 (-2d) |  |  | 1.75d → 1.25d |  | baseline start 2001-09-07 08:00 → 2001-09-04 13:00; baseline finish 2001-09-07 17:00 → 2001-09-05 12:00 |
| 21 | Testing | 2001-09-10 08:00 → 2001-09-05 13:00 (-5d) | 2001-09-10 15:00 → 2001-09-06 10:00 (-4d) |  |  | 1.75d → 1.25d |  | baseline start 2001-09-10 08:00 → 2001-09-05 13:00; baseline finish 2001-09-10 15:00 → 2001-09-06 10:00 |
| 23 | **EdgeTech Integration** | 2001-09-10 15:00 A → 2001-09-06 10:00 A (-4d) | 2001-09-20 17:00 → 2001-09-18 12:00 (-2d) |  |  | 1.38d → 1.19d |  | baseline start 2001-09-10 15:00 → 2001-09-06 10:00; baseline finish 2001-09-20 17:00 → 2001-09-18 12:00 |
| 25 | EdgeTech simulator configuration | 2001-09-10 15:00 A → 2001-09-06 10:00 A (-4d) | 2001-09-10 17:00 → 2001-09-06 12:00 (-4d) |  | 50% → 75% | 9.38d → 9.19d |  | baseline start 2001-09-10 15:00 → 2001-09-06 10:00; baseline finish 2001-09-10 17:00 → 2001-09-06 12:00 |
| 26 | Create DLL and framework. | 2001-09-11 08:00 A → 2001-09-06 13:00 A (-5d) | 2001-09-11 10:00 A → 2001-09-06 15:00 A (-5d) |  |  |  |  | baseline start 2001-09-11 08:00 → 2001-09-06 13:00; baseline finish 2001-09-11 10:00 → 2001-09-06 15:00 |
| 27 | Message handler and socket reciever threads | 2001-09-11 10:00 → 2001-09-06 15:00 (-5d) | 2001-09-12 10:00 → 2001-09-07 15:00 (-5d) |  |  | 1.38d → 0.5d |  | baseline start 2001-09-11 10:00 → 2001-09-06 15:00; baseline finish 2001-09-12 10:00 → 2001-09-07 15:00 |
| 28 | Command and cotrol framework. | 2001-09-12 10:00 → 2001-09-07 15:00 (-5d) | 2001-09-13 10:00 → 2001-09-10 15:00 (-3d) |  |  | 1.38d → 0.5d |  | baseline start 2001-09-12 10:00 → 2001-09-07 15:00; baseline finish 2001-09-13 10:00 → 2001-09-10 15:00 |
| 29 | Data collection framework. | 2001-09-13 10:00 → 2001-09-10 15:00 (-3d) | 2001-09-14 10:00 → 2001-09-11 15:00 (-3d) |  |  | 1.38d → 0.5d |  | baseline start 2001-09-13 10:00 → 2001-09-10 15:00; baseline finish 2001-09-14 10:00 → 2001-09-11 15:00 |
| 30 | Ping/channel sequencer. | 2001-09-14 10:00 → 2001-09-11 15:00 (-3d) | 2001-09-18 10:00 → 2001-09-13 15:00 (-5d) |  |  | 1.38d → 0.5d |  | baseline start 2001-09-14 10:00 → 2001-09-11 15:00; baseline finish 2001-09-18 10:00 → 2001-09-13 15:00 |
| 31 | Sonar configuration save / restore settings. | 2001-09-18 10:00 → 2001-09-13 15:00 (-5d) | 2001-09-18 17:00 → 2001-09-14 12:00 (-4d) |  |  | 1.38d → 0.5d |  | baseline start 2001-09-18 10:00 → 2001-09-13 15:00; baseline finish 2001-09-18 17:00 → 2001-09-14 12:00 |
| 32 | Sonar command set for remote and startup control. | 2001-09-19 08:00 → 2001-09-14 13:00 (-5d) | 2001-09-19 12:00 → 2001-09-14 17:00 (-5d) |  |  | 1.38d → 0.5d |  | baseline start 2001-09-19 08:00 → 2001-09-14 13:00; baseline finish 2001-09-19 12:00 → 2001-09-14 17:00 |
| 33 | Synchronize FS-AS and payload controller clocks. | 2001-09-19 13:00 → 2001-09-17 08:00 (-2d) | 2001-09-19 15:00 → 2001-09-17 10:00 (-2d) |  |  | 1.38d → 0.5d |  | baseline start 2001-09-19 13:00 → 2001-09-17 08:00; baseline finish 2001-09-19 15:00 → 2001-09-17 10:00 |
| 34 | Per channel emulation support (I.e., test patterns). | 2001-09-19 15:00 → 2001-09-17 10:00 (-2d) | 2001-09-19 17:00 → 2001-09-17 12:00 (-2d) |  |  | 1.38d → 0.5d |  | baseline start 2001-09-19 15:00 → 2001-09-17 10:00; baseline finish 2001-09-19 17:00 → 2001-09-17 12:00 |
| 35 | Testing. | 2001-09-20 08:00 → 2001-09-17 13:00 (-3d) | 2001-09-20 17:00 → 2001-09-18 12:00 (-2d) |  |  | 1.38d → 0.5d |  | baseline start 2001-09-20 08:00 → 2001-09-17 13:00; baseline finish 2001-09-20 17:00 → 2001-09-18 12:00 |
| 37 | **Payload Controller** | 2001-09-21 08:00 A → 2001-09-18 13:00 A (-3d) | 2001-10-23 11:00 → 2001-10-22 16:00 (-1d) | 22.38d → 24.38d? |  | 0.88d → 0.38d |  | baseline start 2001-09-21 08:00 → 2001-09-18 13:00; baseline finish 2001-10-23 11:00 → 2001-10-22 16:00 |
| 39 | **General** | 2001-09-21 08:00 A → 2001-09-18 13:00 A (-3d) | 2001-10-02 17:00 → 2001-09-28 12:00 (-4d) |  |  |  |  | baseline start 2001-09-21 08:00 → 2001-09-18 13:00; baseline finish 2001-10-02 17:00 → 2001-09-28 12:00 |
| 41 | Service restructure (polled acquisition cycle, socket exchange, command handler, infrustruture). | 2001-09-21 08:00 A → 2001-09-18 13:00 A (-3d) | 2001-09-24 17:00 → 2001-09-20 12:00 (-4d) |  |  | 1.5d → 0.69d |  | baseline start 2001-09-21 08:00 → 2001-09-18 13:00; baseline finish 2001-09-24 17:00 → 2001-09-20 12:00 |
| 42 | Integrate new sensor list (DLL registration). | 2001-09-25 08:00 → 2001-09-20 13:00 (-5d) | 2001-09-25 12:00 → 2001-09-20 17:00 (-5d) |  |  | 0.88d → 0.69d |  | baseline start 2001-09-25 08:00 → 2001-09-20 13:00; baseline finish 2001-09-25 12:00 → 2001-09-20 17:00 |
| 43 | Rework message handler to be driven by 7k protocol | 2001-09-25 13:00 → 2001-09-21 08:00 (-4d) | 2001-09-27 12:00 → 2001-09-24 17:00 (-3d) |  |  | 0.88d → 0.69d |  | baseline start 2001-09-25 13:00 → 2001-09-21 08:00; baseline finish 2001-09-27 12:00 → 2001-09-24 17:00 |
| 44 | Expand saved and restored parameter list (includes sensor state). | 2001-09-27 13:00 → 2001-09-25 08:00 (-2d) | 2001-09-27 17:00 → 2001-09-25 12:00 (-2d) |  |  | 0.88d → 0.69d |  | baseline start 2001-09-27 13:00 → 2001-09-25 08:00; baseline finish 2001-09-27 17:00 → 2001-09-25 12:00 |
| 45 | UTC time synchronization support. | 2001-09-28 08:00 → 2001-09-25 13:00 (-3d) | 2001-09-28 12:00 → 2001-09-25 17:00 (-3d) |  |  | 0.88d → 0.69d |  | baseline start 2001-09-28 08:00 → 2001-09-25 13:00; baseline finish 2001-09-28 12:00 → 2001-09-25 17:00 |
| 46 | Supervise new sensors. | 2001-09-28 13:00 → 2001-09-26 08:00 (-2d) | 2001-10-01 12:00 → 2001-09-26 17:00 (-5d) |  |  | 0.88d → 0.69d |  | baseline start 2001-09-28 13:00 → 2001-09-26 08:00; baseline finish 2001-10-01 12:00 → 2001-09-26 17:00 |
| 47 | Command routing | 2001-10-01 13:00 → 2001-09-27 08:00 (-4d) | 2001-10-01 17:00 → 2001-09-27 12:00 (-4d) |  |  | 0.88d → 0.69d |  | baseline start 2001-10-01 13:00 → 2001-09-27 08:00; baseline finish 2001-10-01 17:00 → 2001-09-27 12:00 |
| 48 | Testing | 2001-10-02 08:00 → 2001-09-27 13:00 (-5d) | 2001-10-02 17:00 → 2001-09-28 12:00 (-4d) |  |  | 0.88d → 0.69d |  | baseline start 2001-10-02 08:00 → 2001-09-27 13:00; baseline finish 2001-10-02 17:00 → 2001-09-28 12:00 |
| 50 | **Logging** | 2001-10-03 08:00 → 2001-09-28 13:00 (-5d) | 2001-10-05 16:00 → 2001-10-03 11:00 (-2d) |  |  |  | none → 39 | baseline start 2001-10-03 08:00 → 2001-09-28 13:00; baseline finish 2001-10-05 16:00 → 2001-10-03 11:00 |
| 52 | Record sequencing and logging support class(es). | 2001-10-03 08:00 → 2001-09-28 13:00 (-5d) | 2001-10-03 17:00 → 2001-10-01 12:00 (-2d) |  |  | 0.88d → 0.69d |  | baseline start 2001-10-03 08:00 → 2001-09-28 13:00; baseline finish 2001-10-03 17:00 → 2001-10-01 12:00 |
| 53 | Integrate 7k logging API. | 2001-10-04 08:00 → 2001-10-01 13:00 (-3d) | 2001-10-04 12:00 → 2001-10-01 17:00 (-3d) |  |  | 0.88d → 0.69d |  | baseline start 2001-10-04 08:00 → 2001-10-01 13:00; baseline finish 2001-10-04 12:00 → 2001-10-01 17:00 |
| 54 | Auto change of file names on file size and named logging based on time. | 2001-10-04 13:00 → 2001-10-02 08:00 (-2d) | 2001-10-04 15:00 → 2001-10-02 10:00 (-2d) |  |  | 0.88d → 0.69d |  | baseline start 2001-10-04 13:00 → 2001-10-02 08:00; baseline finish 2001-10-04 15:00 → 2001-10-02 10:00 |
| 55 | Periodically flush logging buffers (minimize potential data loss in event of system crash). | 2001-10-04 15:00 → 2001-10-02 10:00 (-2d) | 2001-10-04 16:00 → 2001-10-02 11:00 (-2d) |  |  | 0.88d → 0.69d |  | baseline start 2001-10-04 15:00 → 2001-10-02 10:00; baseline finish 2001-10-04 16:00 → 2001-10-02 11:00 |
| 56 | Testing | 2001-10-04 16:00 → 2001-10-02 11:00 (-2d) | 2001-10-05 16:00 → 2001-10-03 11:00 (-2d) |  |  | 0.88d → 0.69d |  | baseline start 2001-10-04 16:00 → 2001-10-02 11:00; baseline finish 2001-10-05 16:00 → 2001-10-03 11:00 |
| 58 | **Survey Event Log** | 2001-10-05 16:00 A → 2001-10-03 11:00 A (-2d) | 2001-10-09 14:00 → 2001-10-05 09:00 (-4d) |  |  | 0.88d → 2.38d | none → 50 | baseline start 2001-10-05 16:00 → 2001-10-03 11:00; baseline finish 2001-10-09 14:00 → 2001-10-05 09:00 |
| 59 | Re-work infrustructure | 2001-10-05 16:00 A → 2001-10-03 11:00 A (-2d) | 2001-10-09 09:00 → 2001-10-04 14:00 (-5d) |  |  |  |  | baseline start 2001-10-05 16:00 → 2001-10-03 11:00; baseline finish 2001-10-09 09:00 → 2001-10-04 14:00 |
| 60 | Testing | 2001-10-09 09:00 → 2001-10-04 14:00 (-5d) | 2001-10-09 14:00 → 2001-10-05 09:00 (-4d) |  |  | 0.88d → 2.38d |  | baseline start 2001-10-09 09:00 → 2001-10-04 14:00; baseline finish 2001-10-09 14:00 → 2001-10-05 09:00 |
| 62 | **Alarm and Status Monitoring** | 2001-10-09 14:00 → 2001-10-05 09:00 (-4d) | 2001-10-12 16:00 → 2001-10-10 11:00 (-2d) |  |  | 0.88d → 0.38d | none → 58 | baseline start 2001-10-09 14:00 → 2001-10-05 09:00; baseline finish 2001-10-12 16:00 → 2001-10-10 11:00 |
| 63 | Infrastructure | 2001-10-09 14:00 → 2001-10-05 09:00 (-4d) | 2001-10-10 14:00 → 2001-10-08 09:00 (-2d) |  |  | 0.88d → 2.38d |  | baseline start 2001-10-09 14:00 → 2001-10-05 09:00; baseline finish 2001-10-10 14:00 → 2001-10-08 09:00 |
| 64 | Status monitoring | 2001-10-10 14:00 → 2001-10-08 09:00 (-2d) | 2001-10-11 14:00 → 2001-10-09 09:00 (-2d) |  |  | 0.88d → 2.38d |  | baseline start 2001-10-10 14:00 → 2001-10-08 09:00; baseline finish 2001-10-11 14:00 → 2001-10-09 09:00 |
| 65 | Messaging to client(s) and Survey Event Log | 2001-10-11 14:00 → 2001-10-09 09:00 (-2d) | 2001-10-12 11:00 → 2001-10-09 16:00 (-3d) |  |  | 0.88d → 2.38d |  | baseline start 2001-10-11 14:00 → 2001-10-09 09:00; baseline finish 2001-10-12 11:00 → 2001-10-09 16:00 |
| 66 | Testing | 2001-10-12 11:00 → 2001-10-09 16:00 (-3d) | 2001-10-12 16:00 → 2001-10-10 11:00 (-2d) |  |  | 0.88d → 2.38d |  | baseline start 2001-10-12 11:00 → 2001-10-09 16:00; baseline finish 2001-10-12 16:00 → 2001-10-10 11:00 |
| 68 | **Trigger Controller** | 2001-10-12 16:00 → 2001-10-10 11:00 (-2d) | 2001-10-17 11:00 → 2001-10-12 16:00 (-5d) |  |  | 0.88d → 0.38d | none → 62 | baseline start 2001-10-12 16:00 → 2001-10-10 11:00; baseline finish 2001-10-17 11:00 → 2001-10-12 16:00 |
| 69 | Interface definition | 2001-10-12 16:00 → 2001-10-10 11:00 (-2d) | 2001-10-15 16:00 → 2001-10-11 11:00 (-4d) |  |  | 0.88d → 2.38d |  | baseline start 2001-10-12 16:00 → 2001-10-10 11:00; baseline finish 2001-10-15 16:00 → 2001-10-11 11:00 |
| 70 | Interface to payload controller. | 2001-10-15 16:00 → 2001-10-11 11:00 (-4d) | 2001-10-16 11:00 → 2001-10-11 16:00 (-5d) |  |  | 0.88d → 2.38d |  | baseline start 2001-10-15 16:00 → 2001-10-11 11:00; baseline finish 2001-10-16 11:00 → 2001-10-11 16:00 |
| 71 | Software trigger scheme | 2001-10-16 11:00 → 2001-10-11 16:00 (-5d) | 2001-10-16 16:00 → 2001-10-12 11:00 (-4d) |  |  | 0.88d → 2.38d |  | baseline start 2001-10-16 11:00 → 2001-10-11 16:00; baseline finish 2001-10-16 16:00 → 2001-10-12 11:00 |
| 72 | Testing | 2001-10-16 16:00 → 2001-10-12 11:00 (-4d) | 2001-10-17 11:00 → 2001-10-12 16:00 (-5d) |  |  | 0.88d → 2.38d |  | baseline start 2001-10-16 16:00 → 2001-10-12 11:00; baseline finish 2001-10-17 11:00 → 2001-10-12 16:00 |
| 74 | **Vehicle Interfacing** | 2001-10-17 11:00 → 2001-10-12 16:00 (-5d) | 2001-10-23 11:00 → 2001-10-22 16:00 (-1d) | 4d → 6d? |  | 0.88d → 0.38d | none → 68 | baseline start 2001-10-17 11:00 → 2001-10-12 16:00; baseline finish 2001-10-23 11:00 → 2001-10-22 16:00 |
| 76 | Infrastructure. | 2001-10-17 11:00 → 2001-10-16 16:00 (-1d) | 2001-10-17 16:00 → 2001-10-17 11:00 |  |  | 0.88d → 0.38d | 72 → none | baseline start 2001-10-17 11:00 → 2001-10-16 16:00; baseline finish 2001-10-17 16:00 → 2001-10-17 11:00 |
| 77 | Interface to Vehicle computer. | 2001-10-17 16:00 → 2001-10-17 11:00 | 2001-10-18 16:00 → 2001-10-18 11:00 |  |  | 0.88d → 0.38d |  | baseline start 2001-10-17 16:00 → 2001-10-17 11:00; baseline finish 2001-10-18 16:00 → 2001-10-18 11:00 |
| 78 | Interface to CAN system | 2001-10-18 16:00 → 2001-10-18 11:00 | 2001-10-19 16:00 → 2001-10-19 11:00 |  |  | 0.88d → 0.38d |  | baseline start 2001-10-18 16:00 → 2001-10-18 11:00; baseline finish 2001-10-19 16:00 → 2001-10-19 11:00 |
| 79 | Benchmark testing of 100 Hz update rates. | 2001-10-19 16:00 → 2001-10-19 11:00 | 2001-10-22 11:00 → 2001-10-19 16:00 (-3d) |  |  | 0.88d → 0.38d |  | baseline start 2001-10-19 16:00 → 2001-10-19 11:00; baseline finish 2001-10-22 11:00 → 2001-10-19 16:00 |
| 80 | Data formatting | 2001-10-22 11:00 → 2001-10-19 16:00 (-3d) | 2001-10-22 16:00 → 2001-10-22 11:00 |  |  | 0.88d → 0.38d |  | baseline start 2001-10-22 11:00 → 2001-10-19 16:00; baseline finish 2001-10-22 16:00 → 2001-10-22 11:00 |
| 81 | Testing. | 2001-10-22 16:00 → 2001-10-22 11:00 | 2001-10-23 11:00 → 2001-10-22 16:00 (-1d) |  |  | 0.88d → 0.38d |  | baseline start 2001-10-22 16:00 → 2001-10-22 11:00; baseline finish 2001-10-23 11:00 → 2001-10-22 16:00 |
| 83 | **Dry End** |  | 2001-10-19 15:00 → 2001-10-23 10:00 (+4d) | 38.75d → 41.25d |  |  |  | constraint start no earlier than 2001-08-27 08:00 → none; baseline finish 2001-10-19 15:00 → 2001-10-23 10:00 |
| 85 | **Prototyping** |  | 2001-09-11 17:00 → 2001-09-10 17:00 (-1d) |  | 41% → 44% |  |  | baseline finish 2001-09-11 17:00 → 2001-09-10 17:00 |
| 87 | Waterfall display class(es) |  | 2001-09-04 17:00 → 2001-09-03 17:00 (-1d) |  | 75% → 80% |  |  | constraint none → start no earlier than 2001-08-27 08:00; baseline finish 2001-09-04 17:00 → 2001-09-03 17:00 |
| 88 | Timeseries plot class(es) | 2001-09-05 08:00 → 2001-09-04 08:00 (-1d) | 2001-09-11 17:00 → 2001-09-10 17:00 (-1d) |  |  |  |  | baseline start 2001-09-05 08:00 → 2001-09-04 08:00; baseline finish 2001-09-11 17:00 → 2001-09-10 17:00 |
| 90 | **Infrastructure** | 2001-09-12 08:00 → 2001-09-11 08:00 (-1d) | 2001-09-26 17:00 → 2001-09-25 17:00 (-1d) |  |  |  |  | baseline start 2001-09-12 08:00 → 2001-09-11 08:00; baseline finish 2001-09-26 17:00 → 2001-09-25 17:00 |
| 92 | Restructure framework | 2001-09-12 08:00 → 2001-09-11 08:00 (-1d) | 2001-09-18 17:00 → 2001-09-17 17:00 (-1d) |  |  |  |  | baseline start 2001-09-12 08:00 → 2001-09-11 08:00; baseline finish 2001-09-18 17:00 → 2001-09-17 17:00 |

| ID | Task | Start | Finish | Duration | Total float | Predecessors | Other |
| --- | --- | --- | --- | --- | --- | --- | --- |
| 93 | Per sensor setup and control page | 2001-09-19 08:00 → 2001-09-18 08:00 (-1d) | 2001-09-20 17:00 → 2001-09-19 17:00 (-1d) |  |  |  | baseline start 2001-09-19 08:00 → 2001-09-18 08:00; baseline finish 2001-09-20 17:00 → 2001-09-19 17:00 |
| 94 | Message handler object and integration of 7k protocol/socket API. | 2001-09-21 08:00 → 2001-09-20 08:00 (-1d) | 2001-09-24 17:00 → 2001-09-21 17:00 (-3d) |  |  |  | baseline start 2001-09-21 08:00 → 2001-09-20 08:00; baseline finish 2001-09-24 17:00 → 2001-09-21 17:00 |
| 95 | 7k file replay mechanism and integration of 7k data replay DLL | 2001-09-25 08:00 → 2001-09-24 08:00 (-1d) | 2001-09-26 17:00 → 2001-09-25 17:00 (-1d) |  |  |  | baseline start 2001-09-25 08:00 → 2001-09-24 08:00; baseline finish 2001-09-26 17:00 → 2001-09-25 17:00 |
| 97 | **Visualization Displays for Playback** | 2001-09-27 08:00 → 2001-09-26 08:00 (-1d) | 2001-10-12 17:00 → 2001-10-11 17:00 (-1d) |  |  |  | baseline start 2001-09-27 08:00 → 2001-09-26 08:00; baseline finish 2001-10-12 17:00 → 2001-10-11 17:00 |
| 99 | Integrate 7k command protocol API | 2001-09-27 08:00 → 2001-09-26 08:00 (-1d) | 2001-09-27 17:00 → 2001-09-26 17:00 (-1d) |  |  |  | baseline start 2001-09-27 08:00 → 2001-09-26 08:00; baseline finish 2001-09-27 17:00 → 2001-09-26 17:00 |
| 100 | Data scaling and pre-processing | 2001-09-28 08:00 → 2001-09-27 08:00 (-1d) | 2001-10-01 17:00 → 2001-09-28 17:00 (-3d) |  |  |  | baseline start 2001-09-28 08:00 → 2001-09-27 08:00; baseline finish 2001-10-01 17:00 → 2001-09-28 17:00 |
| 101 | Integrate waterfall display for SSS. | 2001-10-02 08:00 → 2001-10-01 08:00 (-1d) | 2001-10-03 12:00 → 2001-10-02 12:00 (-1d) |  |  |  | baseline start 2001-10-02 08:00 → 2001-10-01 08:00; baseline finish 2001-10-03 12:00 → 2001-10-02 12:00 |
| 102 | Integrate waterfall display for SBP. | 2001-10-03 13:00 → 2001-10-02 13:00 (-1d) | 2001-10-04 17:00 → 2001-10-03 17:00 (-1d) |  |  |  | baseline start 2001-10-03 13:00 → 2001-10-02 13:00; baseline finish 2001-10-04 17:00 → 2001-10-03 17:00 |
| 103 | Integrate time series plot graphics and parameter mapping. | 2001-10-05 08:00 → 2001-10-04 08:00 (-1d) | 2001-10-08 17:00 → 2001-10-05 17:00 (-3d) |  |  |  | baseline start 2001-10-05 08:00 → 2001-10-04 08:00; baseline finish 2001-10-08 17:00 → 2001-10-05 17:00 |
| 104 | Tables of position updates. | 2001-10-09 08:00 → 2001-10-08 08:00 (-1d) | 2001-10-09 17:00 → 2001-10-08 17:00 (-1d) |  |  |  | baseline start 2001-10-09 08:00 → 2001-10-08 08:00; baseline finish 2001-10-09 17:00 → 2001-10-08 17:00 |
| 105 | Summary display for ping / time data | 2001-10-10 08:00 → 2001-10-09 08:00 (-1d) | 2001-10-10 17:00 → 2001-10-09 17:00 (-1d) |  |  |  | baseline start 2001-10-10 08:00 → 2001-10-09 08:00; baseline finish 2001-10-10 17:00 → 2001-10-09 17:00 |
| 106 | Testing | 2001-10-11 08:00 → 2001-10-10 08:00 (-1d) | 2001-10-12 17:00 → 2001-10-11 17:00 (-1d) |  |  |  | resources none → JM; baseline start 2001-10-11 08:00 → 2001-10-10 08:00; baseline finish 2001-10-12 17:00 → 2001-10-11 17:00 |
| 108 | **GUIs for payload controller** | 2001-10-15 08:00 → 2001-10-12 08:00 (-3d) | 2001-10-19 15:00 → 2001-10-18 15:00 (-1d) |  |  |  | baseline start 2001-10-15 08:00 → 2001-10-12 08:00; baseline finish 2001-10-19 15:00 → 2001-10-18 15:00 |
| 110 | Setup, control and status review of sensors (sensor specific). | 2001-10-15 08:00 → 2001-10-12 08:00 (-3d) | 2001-10-17 12:00 → 2001-10-16 12:00 (-1d) |  |  |  | baseline start 2001-10-15 08:00 → 2001-10-12 08:00; baseline finish 2001-10-17 12:00 → 2001-10-16 12:00 |
| 111 | GUI for setup and synchronization scheme. | 2001-10-17 13:00 → 2001-10-16 13:00 (-1d) | 2001-10-18 15:00 → 2001-10-17 15:00 (-1d) |  |  |  | baseline start 2001-10-17 13:00 → 2001-10-16 13:00; baseline finish 2001-10-18 15:00 → 2001-10-17 15:00 |
| 112 | Sensor data received summary page | 2001-10-18 15:00 → 2001-10-17 15:00 (-1d) | 2001-10-19 15:00 → 2001-10-18 15:00 (-1d) |  |  |  | baseline start 2001-10-18 15:00 → 2001-10-17 15:00; baseline finish 2001-10-19 15:00 → 2001-10-18 15:00 |
| 114 | **Installation Program** | 2001-10-19 15:00 → 2001-10-18 15:00 (-1d) | 2001-10-24 10:00 → 2001-10-23 10:00 (-1d) |  |  | 108, 83 → 108 | baseline start 2001-10-19 15:00 → 2001-10-18 15:00; baseline finish 2001-10-24 10:00 → 2001-10-23 10:00 |
| 116 | Generate install scripts | 2001-10-19 15:00 → 2001-10-18 15:00 (-1d) | 2001-10-23 15:00 → 2001-10-22 15:00 (-1d) |  |  |  | baseline start 2001-10-19 15:00 → 2001-10-18 15:00; baseline finish 2001-10-23 15:00 → 2001-10-22 15:00 |
| 117 | Testing | 2001-10-23 15:00 → 2001-10-22 15:00 (-1d) | 2001-10-24 10:00 → 2001-10-23 10:00 (-1d) |  |  |  | baseline start 2001-10-23 15:00 → 2001-10-22 15:00; baseline finish 2001-10-24 10:00 → 2001-10-23 10:00 |
| 119 | **Integration testing** | 2001-10-24 10:00 → 2001-10-23 10:00 (-1d) | 2001-10-30 15:00 → 2001-10-30 10:00 | 4.5d → 5d |  | 114, 37, 13 → 114, 37, 13, 83 | baseline start 2001-10-24 10:00 → 2001-10-23 10:00; baseline finish 2001-10-30 15:00 → 2001-10-30 10:00 |
| 121 | Setup hardware | 2001-10-24 10:00 → 2001-10-23 10:00 (-1d) | 2001-10-24 15:00 → 2001-10-23 15:00 (-1d) |  |  |  | baseline start 2001-10-24 10:00 → 2001-10-23 10:00; baseline finish 2001-10-24 15:00 → 2001-10-23 15:00 |
| 122 | Configure software and tools | 2001-10-24 10:00 → 2001-10-23 15:00 (-1d) | 2001-10-24 15:00 → 2001-10-24 10:00 |  |  | 117 → 117, 121 | baseline start 2001-10-24 10:00 → 2001-10-23 15:00; baseline finish 2001-10-24 15:00 → 2001-10-24 10:00 |
| 123 | Testing and debugging | 2001-10-24 15:00 → 2001-10-24 10:00 | 2001-10-30 15:00 → 2001-10-30 10:00 |  |  |  | baseline start 2001-10-24 15:00 → 2001-10-24 10:00; baseline finish 2001-10-30 15:00 → 2001-10-30 10:00 |
| 125 | **Utilities** | 2001-10-30 15:00 → 2001-10-30 10:00 | 2001-11-01 15:00 → 2001-11-01 10:00 |  |  |  | baseline start 2001-10-30 15:00 → 2001-10-30 10:00; baseline finish 2001-11-01 15:00 → 2001-11-01 10:00 |
| 127 | 7k to XTF conversion utility | 2001-10-30 15:00 → 2001-10-30 10:00 | 2001-11-01 15:00 → 2001-11-01 10:00 |  |  |  | baseline start 2001-10-30 15:00 → 2001-10-30 10:00; baseline finish 2001-11-01 15:00 → 2001-11-01 10:00 |
| 129 | **PHASE II** | 2001-11-01 15:00 → 2001-11-01 10:00 | 2001-12-25 10:00 → 2001-12-24 15:00 (-1d) |  |  | 1, 125 → 1 | baseline start 2001-11-01 15:00 → 2001-11-01 10:00; baseline finish 2001-12-25 10:00 → 2001-12-24 15:00 |
| 131 | **Wet End** | 2001-11-01 15:00 → 2001-11-01 10:00 | 2001-11-13 10:00 → 2001-11-12 15:00 (-1d) |  |  |  | baseline start 2001-11-01 15:00 → 2001-11-01 10:00; baseline finish 2001-11-13 10:00 → 2001-11-12 15:00 |
| 133 | Direct logging of XTF | 2001-11-01 15:00 → 2001-11-01 10:00 | 2001-11-05 15:00 → 2001-11-05 10:00 |  |  |  | baseline start 2001-11-01 15:00 → 2001-11-01 10:00; baseline finish 2001-11-05 15:00 → 2001-11-05 10:00 |
| 134 | Data messages for realtime display | 2001-11-05 15:00 → 2001-11-05 10:00 | 2001-11-07 15:00 → 2001-11-07 10:00 |  |  |  | baseline start 2001-11-05 15:00 → 2001-11-05 10:00; baseline finish 2001-11-07 15:00 → 2001-11-07 10:00 |
| 135 | Collect logging statistics | 2001-11-07 15:00 → 2001-11-07 10:00 | 2001-11-08 10:00 → 2001-11-07 15:00 (-1d) |  |  |  | baseline start 2001-11-07 15:00 → 2001-11-07 10:00; baseline finish 2001-11-08 10:00 → 2001-11-07 15:00 |
| 136 | Re-work Timing Controller for HW supervision | 2001-11-08 10:00 → 2001-11-07 15:00 (-1d) | 2001-11-13 10:00 → 2001-11-12 15:00 (-1d) |  |  |  | baseline start 2001-11-08 10:00 → 2001-11-07 15:00; baseline finish 2001-11-13 10:00 → 2001-11-12 15:00 |
| 138 | **Dry End** | 2001-11-01 15:00 → 2001-11-01 10:00 | 2001-11-02 10:00 → 2001-11-01 15:00 (-1d) |  |  | 119 → none | baseline start 2001-11-01 15:00 → 2001-11-01 10:00; baseline finish 2001-11-02 10:00 → 2001-11-01 15:00 |
| 140 | Realtime display integration | 2001-11-01 15:00 → 2001-11-01 10:00 | 2001-11-02 10:00 → 2001-11-01 15:00 (-1d) |  |  |  | baseline start 2001-11-01 15:00 → 2001-11-01 10:00; baseline finish 2001-11-02 10:00 → 2001-11-01 15:00 |
| 142 | **QC (TBD - Subject to proposal acceptance)** | 2001-11-13 10:00 → 2001-11-12 15:00 (-1d) | 2001-12-25 10:00 → 2001-12-24 15:00 (-1d) |  |  |  | baseline start 2001-11-13 10:00 → 2001-11-12 15:00; baseline finish 2001-12-25 10:00 → 2001-12-24 15:00 |
| 143 | TBD | 2001-11-13 10:00 → 2001-11-12 15:00 (-1d) | 2001-12-25 10:00 → 2001-12-24 15:00 (-1d) |  |  |  | baseline start 2001-11-13 10:00 → 2001-11-12 15:00; baseline finish 2001-12-25 10:00 → 2001-12-24 15:00 |
| 145 | Initial release | 2001-10-30 15:00 → 2001-11-01 10:00 (+2d) | 2001-10-30 15:00 → 2001-11-01 10:00 (+2d) |  | 39.5d → 37.5d | 119 → 123, 1 | baseline start 2001-10-30 15:00 → 2001-11-01 10:00; baseline finish 2001-10-30 15:00 → 2001-11-01 10:00 |
| 146 | Final release | 2001-12-25 10:00 → 2001-12-24 15:00 (-1d) | 2001-12-25 10:00 → 2001-12-24 15:00 (-1d) |  |  | 129, 142, 138, 140 → 143, 140, 138, 142 | baseline start 2001-12-25 10:00 → 2001-12-24 15:00; baseline finish 2001-12-25 10:00 → 2001-12-24 15:00 |
| 148 | **PHASE III (unscheduled - future work)** | 2001-07-30 08:00 → 2001-09-04 08:00 (+36d) | 2001-07-30 08:00 → 2001-09-04 08:00 (+36d) |  | 105.25d → 79.75d |  | baseline start 2001-07-30 08:00 → 2001-09-04 08:00; baseline finish 2001-07-30 08:00 → 2001-09-04 08:00 |
| 150 | **Dry End** | 2001-07-30 08:00 → 2001-09-04 08:00 (+36d) | 2001-07-30 08:00 → 2001-09-04 08:00 (+36d) |  | 105.25d → 79.75d |  | baseline start 2001-07-30 08:00 → 2001-09-04 08:00; baseline finish 2001-07-30 08:00 → 2001-09-04 08:00 |
| 152 | File transfer GUI and control. | 2001-07-30 08:00 → 2001-09-04 08:00 (+36d) | 2001-07-30 08:00 → 2001-09-04 08:00 (+36d) |  | 105.25d → 79.75d |  | baseline start 2001-07-30 08:00 → 2001-09-04 08:00; baseline finish 2001-07-30 08:00 → 2001-09-04 08:00 |
| 154 | **Wet End** | 2001-07-30 08:00 → 2001-09-04 08:00 (+36d) | 2001-07-30 08:00 → 2001-09-04 08:00 (+36d) |  | 105.25d → 79.75d |  | baseline start 2001-07-30 08:00 → 2001-09-04 08:00; baseline finish 2001-07-30 08:00 → 2001-09-04 08:00 |
| 156 | File transferPLC support. | 2001-07-30 08:00 → 2001-09-04 08:00 (+36d) | 2001-07-30 08:00 → 2001-09-04 08:00 (+36d) |  | 105.25d → 79.75d |  | baseline start 2001-07-30 08:00 → 2001-09-04 08:00; baseline finish 2001-07-30 08:00 → 2001-09-04 08:00 |
| 157 | Serial port handler w/ time tagging. | 2001-07-30 08:00 → 2001-09-04 08:00 (+36d) | 2001-07-30 08:00 → 2001-09-04 08:00 (+36d) |  | 105.25d → 79.75d |  | baseline start 2001-07-30 08:00 → 2001-09-04 08:00; baseline finish 2001-07-30 08:00 → 2001-09-04 08:00 |
| 158 | Optionally send Patch Test messages. | 2001-07-30 08:00 → 2001-09-04 08:00 (+36d) | 2001-07-30 08:00 → 2001-09-04 08:00 (+36d) |  | 105.25d → 79.75d |  | baseline start 2001-07-30 08:00 → 2001-09-04 08:00; baseline finish 2001-07-30 08:00 → 2001-09-04 08:00 |
| 159 | Interface to 6041. | 2001-07-30 08:00 → 2001-09-04 08:00 (+36d) | 2001-07-30 08:00 → 2001-09-04 08:00 (+36d) |  | 105.25d → 79.75d |  | baseline start 2001-07-30 08:00 → 2001-09-04 08:00; baseline finish 2001-07-30 08:00 → 2001-09-04 08:00 |

## Version 3 (saved 2001-10-01, file Project Schedule Phase 1 and 2 (rev 5).mpp)

Last finish 2001-12-24 → 2002-01-02 (+9d). Complete tasks 4 → 6.

Added:

| ID | Task | Duration | Start | Finish | Predecessors | Resources |
| --- | --- | --- | --- | --- | --- | --- |
| 128 | 7k data access classes | 16h | 2001-11-01 10:00 | 2001-11-05 10:00 | 127 | WA |
| 139 | **7k Sonar Integration** | 5.25d | 2001-11-14 15:00 | 2001-11-21 17:00 |  |  |
| 141 | Create DLL and framework | 2h | 2001-11-14 15:00 | 2001-11-14 17:00 | 137 | WA |
| 142 | Sonar data interface | 16h | 2001-11-15 08:00 | 2001-11-16 17:00 | 141 | WA |
| 143 | Logging | 2h | 2001-11-19 08:00 | 2001-11-19 10:00 | 142 | WA |
| 144 | Time sync | 6h | 2001-11-19 10:00 | 2001-11-19 17:00 | 143 | WA |
| 145 | Trigger controller interface | 8h | 2001-11-20 08:00 | 2001-11-20 17:00 | 144 | WA |
| 146 | Testing | 8h | 2001-11-21 08:00 | 2001-11-21 17:00 | 145 | WA |

Changed:

| ID | Task | Start | Finish | Duration | Complete | Total float | Predecessors | Other |
| --- | --- | --- | --- | --- | --- | --- | --- | --- |
| 1 | **PHASE I** |  | 2001-11-01 10:00 → 2001-11-05 10:00 (+4d) | 58.25d? → 60.25d | 21% → 25% |  |  |  |
| 3 | **Project Planning and Specification** |  |  |  | 88% → 94% | 8.44d → 13.84d |  |  |
| 7 | Rework 6046 SW specification |  |  |  | 90% → 95% | 7.81d → 11.99d |  |  |
| 8 | QC proposal |  |  |  | 70% → 90% | 9.56d → 12.21d |  |  |
| 11 | Define 7k records for EdgeTech SSS, SBP and sundry sensors |  |  |  | 75% → 90% | 5.75d → 13.84d |  |  |
| 13 | **Wet End** |  | 2001-10-22 16:00 → 2001-10-18 16:00 (-4d) | 42.38d? → 40.38d | 19% → 29% | 0.38d → 2.38d |  |  |
| 15 | **General** |  |  |  | 67% → 81% | 1.62d → 5.94d |  |  |
| 17 | Time, timing and general support classes. |  | 2001-08-29 12:00 A |  | 90% → 100% | 4.15d → none |  |  |
| 18 | Socket support classes. |  | 2001-08-31 12:00 A |  | 85% → 100% | 2.45d → none |  |  |
| 19 | 7k protocol, disk I/0 and socket framing API (DLL). |  |  |  | 60% → 95% | 1.25d → 1.94d |  |  |
| 23 | **EdgeTech Integration** |  |  |  | 5% → 24% | 1.19d → 4d |  |  |
| 27 | Message handler and socket reciever threads | 2001-09-06 15:00 A |  |  | 0% → 75% | 0.5d → 1.25d |  |  |
| 29 | Data collection framework. | 2001-09-10 15:00 A |  |  | 0% → 80% |  |  |  |
| 37 | **Payload Controller** |  | 2001-10-22 16:00 → 2001-10-18 16:00 (-4d) | 24.38d? → 22.38d | 5% → 7% | 0.38d → 2.38d |  |  |
| 39 | **General** |  |  |  | 6% → 13% | 1.5d → 3d |  |  |
| 41 | Service restructure (polled acquisition cycle, socket exchange, command handler, infrustruture). |  |  |  | 25% → 50% | 0.69d → 3d |  |  |
| 54 | Auto change of file names on file size and named logging based on time with overlap. |  |  |  |  |  |  | was named Auto change of file names on file size and named logging based on time. |
| 74 | **Vehicle Interfacing** |  | 2001-10-22 16:00 → 2001-10-18 16:00 (-4d) | 6d? → 4d |  | 0.38d → 2.38d |  |  |
| 76 | Infrastructure. | 2001-10-16 16:00 → 2001-10-12 16:00 (-4d) | 2001-10-17 11:00 → 2001-10-15 11:00 (-2d) |  |  | 0.38d → 2.38d | none → 72 |  |
| 77 | Interface to Vehicle computer. | 2001-10-17 11:00 → 2001-10-15 11:00 (-2d) | 2001-10-18 11:00 → 2001-10-16 11:00 (-2d) |  |  | 0.38d → 2.38d |  |  |
| 78 | Interface to CAN system | 2001-10-18 11:00 → 2001-10-16 11:00 (-2d) | 2001-10-19 11:00 → 2001-10-17 11:00 (-2d) |  |  | 0.38d → 2.38d |  |  |
| 79 | Benchmark testing of 100 Hz update rates. | 2001-10-19 11:00 → 2001-10-17 11:00 (-2d) | 2001-10-19 16:00 → 2001-10-17 16:00 (-2d) |  |  | 0.38d → 2.38d |  |  |
| 80 | Data formatting | 2001-10-19 16:00 → 2001-10-17 16:00 (-2d) | 2001-10-22 11:00 → 2001-10-18 11:00 (-4d) |  |  | 0.38d → 2.38d |  |  |
| 81 | Testing. | 2001-10-22 11:00 → 2001-10-18 11:00 (-4d) | 2001-10-22 16:00 → 2001-10-18 16:00 (-4d) |  |  | 0.38d → 2.38d |  |  |
| 85 | **Prototyping** |  |  |  | 44% → 46% |  |  |  |
| 87 | Waterfall display class(es) |  |  |  | 80% → 85% |  |  |  |
| 125 | **Utilities** |  | 2001-11-01 10:00 → 2001-11-05 10:00 (+4d) | 2d → 4d |  |  |  |  |
| 130 | **PHASE II** | 2001-11-01 10:00 → 2001-11-05 10:00 (+4d) | 2001-12-24 15:00 → 2002-01-02 17:00 (+9d) | 37.5d → 42.75d |  |  |  |  |
| 132 | **Wet End** | 2001-11-01 10:00 → 2001-11-05 10:00 (+4d) | 2001-11-12 15:00 → 2001-11-14 15:00 (+2d) |  |  |  |  |  |
| 134 | Direct logging of XTF | 2001-11-01 10:00 → 2001-11-05 10:00 (+4d) | 2001-11-05 10:00 → 2001-11-07 10:00 (+2d) |  |  |  | 127 → 128 |  |
| 135 | Data messages for realtime display | 2001-11-05 10:00 → 2001-11-07 10:00 (+2d) | 2001-11-07 10:00 → 2001-11-09 10:00 (+2d) |  |  |  |  |  |
| 136 | Collect logging statistics | 2001-11-07 10:00 → 2001-11-09 10:00 (+2d) | 2001-11-07 15:00 → 2001-11-09 15:00 (+2d) |  |  |  |  |  |
| 137 | Re-work Timing Controller for HW supervision | 2001-11-07 15:00 → 2001-11-09 15:00 (+2d) | 2001-11-12 15:00 → 2001-11-14 15:00 (+2d) |  |  |  |  |  |
| 148 | **Dry End** | 2001-11-01 10:00 → 2001-11-05 10:00 (+4d) | 2001-11-01 15:00 → 2001-11-05 15:00 (+4d) |  |  | 37d → 42.25d |  |  |
| 150 | Realtime display integration | 2001-11-01 10:00 → 2001-11-05 10:00 (+4d) | 2001-11-01 15:00 → 2001-11-05 15:00 (+4d) |  |  | 37d → 42.25d |  |  |
| 152 | **QC (TBD - Subject to proposal acceptance)** | 2001-11-12 15:00 → 2001-11-22 08:00 (+10d) | 2001-12-24 15:00 → 2002-01-02 17:00 (+9d) |  |  |  |  |  |
| 153 | TBD | 2001-11-12 15:00 → 2001-11-22 08:00 (+10d) | 2001-12-24 15:00 → 2002-01-02 17:00 (+9d) |  |  |  | 137 → 146 |  |
| 155 | Initial release | 2001-11-01 10:00 → 2001-11-05 10:00 (+4d) | 2001-11-01 10:00 → 2001-11-05 10:00 (+4d) |  |  | 37.5d → 42.75d |  |  |
| 156 | Final release | 2001-12-24 15:00 → 2002-01-02 17:00 (+9d) | 2001-12-24 15:00 → 2002-01-02 17:00 (+9d) |  |  |  | 153, 150, 148, 152 → 153, 150, 148, 152, 123 |  |
